| id | name | startDate | endDate | priority | barScale | progress | type | parentId | dependencies |
| --- | --- | --- | --- | --- | --- | --- | --- | --- | --- |
| 1 | Planificación de Eventos | 2026-06-01T00:00:00.000Z | 2026-08-10T00:00:00.000Z | medium | 1 | 0 | group |  |  |
| 2 | Definir objetivos e indicadores de éxito | 2026-06-01T00:00:00.000Z | 2026-06-06T00:00:00.000Z | high | 1 | 0 | task | 1 |  |
| 3 | Fijar el presupuesto del evento | 2026-06-04T00:00:00.000Z | 2026-06-11T00:00:00.000Z | medium | 1 | 0 | task | 1 |  |
| 4 | Preseleccionar y visitar sedes | 2026-06-06T00:00:00.000Z | 2026-06-15T00:00:00.000Z | medium | 1 | 0 | task | 1 | 2 FS |
| 5 | Reservar sede y confirmar fecha | 2026-06-15T00:00:00.000Z | 2026-06-16T00:00:00.000Z | high | 1 | 0 | milestone | 1 | 4 FS |
| 6 | Reservar catering y cerrar el menú | 2026-06-16T00:00:00.000Z | 2026-06-28T00:00:00.000Z | medium | 1 | 0 | task | 1 | 5 FS |
| 7 | Reservar proveedor de audiovisuales | 2026-06-16T00:00:00.000Z | 2026-06-26T00:00:00.000Z | medium | 1 | 0 | task | 1 | 5 FS |
| 8 | Reservar alquiler (mobiliario, carpa, decoración) | 2026-06-16T00:00:00.000Z | 2026-06-26T00:00:00.000Z | medium | 1 | 0 | task | 1 | 5 FS |
| 9 | Redactar la escaleta del evento | 2026-06-21T00:00:00.000Z | 2026-07-01T00:00:00.000Z | medium | 1 | 0 | task | 1 | 5 FS |
| 10 | Lanzar registro e invitaciones | 2026-06-29T00:00:00.000Z | 2026-07-06T00:00:00.000Z | medium | 1 | 0 | task | 1 | 5 FS |
| 11 | Ejecutar campaña de marketing y promoción | 2026-06-29T00:00:00.000Z | 2026-07-19T00:00:00.000Z | medium | 1 | 0 | task | 1 | 5 FS |
| 12 | Registrar confirmaciones, menús y accesibilidad | 2026-07-06T00:00:00.000Z | 2026-07-26T00:00:00.000Z | medium | 1 | 0 | task | 1 | 10 FS |
| 13 | Reclutar y confirmar personal/voluntarios | 2026-07-06T00:00:00.000Z | 2026-07-20T00:00:00.000Z | high | 1 | 0 | task | 1 |  |
| 14 | Ultimar plano, señalización y montaje | 2026-07-13T00:00:00.000Z | 2026-07-27T00:00:00.000Z | medium | 1 | 0 | task | 1 | 8 FS |
| 15 | Informar a personal y voluntarios de roles | 2026-07-20T00:00:00.000Z | 2026-07-23T00:00:00.000Z | medium | 1 | 0 | task | 1 | 13 FS |
| 16 | Confirmar aforo final con proveedores | 2026-07-26T00:00:00.000Z | 2026-07-27T00:00:00.000Z | high | 1 | 0 | milestone | 1 | 12 FS |
| 17 | Recorrido final por la sede | 2026-07-27T00:00:00.000Z | 2026-07-29T00:00:00.000Z | medium | 1 | 0 | task | 1 | 16 FS |
| 18 | Día del evento | 2026-08-03T00:00:00.000Z | 2026-08-04T00:00:00.000Z | high | 1 | 0 | milestone | 1 | 17 FS |
| 19 | Enviar agradecimientos | 2026-08-04T00:00:00.000Z | 2026-08-07T00:00:00.000Z | medium | 1 | 0 | task | 1 | 18 FS |
| 20 | Balance final del evento | 2026-08-07T00:00:00.000Z | 2026-08-10T00:00:00.000Z | medium | 1 | 0 | task | 1 | 19 FS |
